# Squeezing upgrade in aLIGO L1 - 2017

Schedule from GanttProject, 2017-02-01 to 2018-03-01.

## Calendars

- Project calendar: Mon-Fri working; Sat-Sun off.

## Schedule

| ID | WBS | Task | Type | Duration | Start | Finish | Predecessors |
| --- | --- | --- | --- | --- | --- | --- | --- |
| 1 | 1 | **In-air SQZ tables procurement** |  | 183d | 2017-02-01 | 2017-10-13 |  |
| 2 | 1.1 | Laser/optics/opto-mech |  | 120d | 2017-02-16 | 2017-08-02 |  |
| 3 | 1.2 | Fabrice in-air fibers on site (for 532nm and 1064nm CLF/Seed) | milestone | 0d | 2017-07-28 | 2017-07-28 |  |
| 4 | 1.3 | **Electronics** |  | 183d | 2017-02-01 | 2017-10-13 |  |
| 5 | 1.3.1 | RF/slow control |  | 119d | 2017-02-16 | 2017-08-01 |  |
| 6 | 1.3.2 | in-air cables on site |  | 1d | 2017-10-02 | 2017-10-02 |  |
| 7 | 1.3.3 | **CIT electr/photodet** |  | 183d | 2017-02-01 | 2017-10-13 |  |
| 8 | 1.3.3.1 | VOPO SUS coil-drivers (already on site, test-end) |  | 108d | 2017-02-01 | 2017-06-30 |  |
| 9 | 1.3.3.2 | HAM5 and HAM6 tip-tilt coil-drivers on site | milestone | 0d | 2017-10-16 | 2017-10-16 |  |
| 10 | 1.3.3.3 | In-air photodetectors for SQZT6 on site | milestone | 0d | 2017-10-16 | 2017-10-16 |  |
| 11 | 1.3.3.4 | VOPO cavity and HAM6 in-vacuum cables on site | milestone | 0d | 2017-10-16 | 2017-10-16 |  |
| 12 | 2 | Squeezer assembly in room near LVEA entrance |  | 120d | 2017-04-17 | 2017-09-29 |  |
| 13 | 3 | ISCT6 moves to LVEA, laser hazard area around ISCT6 | milestone | 0d | 2017-10-09 | 2017-10-09 |  |
| 14 | 4 | **SQZ work in LVEA** |  | 20d | 2017-10-02 | 2017-10-27 |  |
| 15 | 4.1 | **Electronics work** |  | 20d | 2017-10-02 | 2017-10-27 | 5 |
| 16 | 4.1.1 | install racks, power supplies and RF distribution |  | 10d | 2017-10-02 | 2017-10-13 |  |
| 17 | 4.1.2 | install chassis |  | 10d | 2017-10-02 | 2017-10-13 |  |
| 18 | 4.1.3 | pull cables for controls, short-run RF cables |  | 10d | 2017-10-02 | 2017-10-13 |  |
| 19 | 4.1.4 | slow control and DAQ checkout |  | 5d | 2017-10-16 | 2017-10-20 |  |
| 20 | 4.1.5 | install electronics for HAM5 and HAM6 tip-tilt |  | 5d | 2017-10-23 | 2017-10-27 |  |
| 21 | 4.1.6 | move VOPO SUS electronics from test-end to LVEA |  | 5d | 2017-10-23 | 2017-10-27 |  |
| 22 | 4.2 | Run 100m long fibers from PSL |  | 5d | 2017-10-02 | 2017-10-06 |  |
| 23 | 4.3 | **Configure SQZ with electronics (SHG, AOMs, diodes, TTFSS)** |  | 10d | 2017-10-16 | 2017-10-27 |  |
| 24 | 4.3.1 | Lock SHG |  | 5d | 2017-10-16 | 2017-10-20 |  |
| 25 | 4.3.2 | If possible, test PSL fibers and TTFSS lock (when PSL and TTFSS available) |  | 5d | 2017-10-23 | 2017-10-27 |  |
| 26 | 5 | Squeezer table assembly ready | milestone | 0d | 2017-10-30 | 2017-10-30 | 14 |

Notes:
- 14: Requires laser safe area around tables
- 15: Some work can start during O2 Tuesday maintanance/ run measurement close-out

| ID | WBS | Task | Type | Duration | Start | Finish | Predecessors |
| --- | --- | --- | --- | --- | --- | --- | --- |
| 27 | 6 | **In-vacuum components** |  | 186d | 2017-02-20 | 2017-11-06 |  |
| 28 | 6.1 | **VOPO cavity** |  | 152d | 2017-03-06 | 2017-10-03 |  |
| 29 | 6.1.1 | FDR #2 documents ready | milestone | 0d | 2017-03-06 | 2017-03-06 |  |
| 30 | 6.1.2 | FDR #2 review completed | milestone | 0d | 2017-03-21 | 2017-03-21 |  |
| 31 | 6.1.3 | Procurement (Limerick) |  | 34d | 2017-04-25 | 2017-06-09 |  |
| 32 | 6.1.4 | Cleaning @ LLO |  | 45d | 2017-06-20 | 2017-08-21 |  |
| 33 | 6.1.5 | Assembly and testing @ MIT |  | 30d | 2017-08-22 | 2017-10-02 |  |
| 34 | 6.1.6 | VOPO cavity ready to ship to LLO | milestone | 0d | 2017-10-04 | 2017-10-04 |  |
| 35 | 6.2 | **Fiber patch cords and feedthroughs** |  | 17d | 2017-09-27 | 2017-10-19 |  |
| 36 | 6.2.1 | Fiber feedthroughs C&B, leak check at MIT |  | 13d | 2017-09-27 | 2017-10-13 |  |
| 37 | 6.2.2 | Fibers on site | milestone | 0d | 2017-10-13 | 2017-10-13 |  |
| 38 | 6.2.3 | Feedthroughs on site | milestone | 0d | 2017-10-20 | 2017-10-20 |  |
| 39 | 6.3 | **VOPO Suspension** |  | 176d | 2017-02-20 | 2017-10-23 |  |
| 40 | 6.3.1 | Procurement and cleaning |  | 75d | 2017-02-20 | 2017-06-02 |  |
| 41 | 6.3.2 | Assembly @LHO |  | 15d | 2017-06-05 | 2017-06-23 | 40 |
| 42 | 6.3.3 | Finish assembly @ LLO |  | 10d | 2017-07-10 | 2017-07-21 | 41FS+10d |
| 43 | 6.3.4 | Basic TFs meas and damping loops - Test stand |  | 38d | 2017-07-24 | 2017-09-13 | 42 |
| 44 | 6.3.5 | Class B components for VOPO installation in HAM6 ready | milestone | 0d | 2017-10-23 | 2017-10-23 |  |
| 45 | 6.3.6 | HAM6 ARM ready |  | 1d | 2017-10-23 | 2017-10-23 |  |
| 46 | 6.4 | **VOPO injection platform (VIP)** |  | 76d | 2017-07-24 | 2017-11-06 | 41 |
| 47 | 6.4.1 | Component inspection, testing, cleaning |  | 60d | 2017-07-24 | 2017-10-13 |  |
| 48 | 6.4.2 | VOPO cavity on site | milestone | 0d | 2017-10-11 | 2017-10-11 | 34FS+5d |
| 49 | 6.4.3 | VOPO integration on VIP |  | 10d | 2017-10-24 | 2017-11-06 | 39, 48 |
| 50 | 6.4.4 | Cable and stages check |  | 2d | 2017-10-24 | 2017-10-25 |  |
| 51 | 6.4.5 | VIP ready to move | milestone | 0d | 2017-10-25 | 2017-10-25 |  |
| 52 | 6.5 | HAM6 tip-tilt assembly |  | 5d | 2017-10-02 | 2017-10-06 |  |
| 53 | 6.6 | HAM6 Feed-throughs installation (C1 and D4) |  | 5d | 2017-10-23 | 2017-10-27 |  |

Notes:
- 47: Still to C&B: / * diodes / * diode enclosures / *screws for diode / * collimator adapters
- 49: Including re-positioning of OPO crystal and check of OPO escape efficiency

| ID | WBS | Task | Type | Duration | Start | Finish | Predecessors |
| --- | --- | --- | --- | --- | --- | --- | --- |
| 54 | 7 | **Integration** |  | 88d | 2017-10-30 | 2018-02-28 |  |
| 55 | 7.1 | VOPO installation in HAM6 |  | 10d | 2017-10-30 | 2017-11-10 |  |
| 56 | 7.2 | **VOPO lock in air** |  | 23d | 2017-11-13 | 2017-12-13 | 55 |
| 57 | 7.2.1 | Finish assembly SQZT6 |  | 10d | 2017-11-13 | 2017-11-24 |  |
| 58 | 7.2.2 | Lock/OPO CLF |  | 10d | 2017-11-27 | 2017-12-08 | 57 |
| 59 | 7.2.3 | ISCT6/SQZT6 Slow control interface, DAQ models, basic auto-locker |  | 23d | 2017-11-13 | 2017-12-13 |  |
| 60 | 7.3 | Alignment/mode match check to OMC single bounce (need CLF/SEED beam) |  | 6d | 2017-12-14 | 2017-12-21 | 56 |
| 61 | 7.4 | In-vacuum measurements during full IFO commissioning break (TBD) |  | 49d | 2017-12-22 | 2018-02-28 | 60 |
| 62 | 8 | Standalone SQZ testing / commissioning with full IFO (TBD) | milestone | 0d | 2018-03-01 | 2018-03-01 | 54 |

Notes:
- 62: This part is to be decided depending on IFO configuration
